# SamplePortalProject

Schedule from MS Project, 2006-01-01 to 2006-01-27, status date 2006-01-01.
IBM

## Calendars

- Standard: Mon-Fri 08:00-12:00, 13:00-17:00; Sat-Sun off.

## Resources

| Resource |
| --- |
| Development Lead |
| IBM Sales |
| IBM Tech Sales |
| Project Owner |
| Project Manager |
| Infrastructure Lead |
| Architect |
| IBM Services |
| Test Lead |
| Developers |

## Schedule

| ID | WBS | Task | Type | Duration | Start | Finish | Total slack | Resources | Work |
| --- | --- | --- | --- | --- | --- | --- | --- | --- | --- |
| 1 | 1 | **Overall Notes** |  | 0d | 2006-01-01 | 2006-01-01 | 0d |  |  |
| 2 | 1.1 | Sample WebSphere Portal Project Plan V5.1a | milestone | 0d | 2006-01-01 | 2006-01-01 | 0d |  |  |
| 3 | 1.2 | **Prepared by:** |  | 0d | 2006-01-01 | 2006-01-01 | 0d |  |  |
| 4 | 1.2.1 | IBM Software Services for Lotus | milestone | 0d | 2006-01-01 | 2006-01-01 | 0d |  |  |
| 5 | 1.2.2 | Portal Technology Team | milestone | 0d | 2006-01-01 | 2006-01-01 | 0d |  |  |
| 6 | 1.2.3 | Ken Polleck, Senior Practice Manager | milestone | 0d | 2006-01-01 | 2006-01-01 | 0d |  |  |
| 7 | 1.2.4 | kpolleck@us.ibm.com | milestone | 0d | 2006-01-01 | 2006-01-01 | 0d |  |  |
| 8 | 1.2.5 | Prepared in Microsoft Project 2002 | milestone | 0d | 2006-01-01 | 2006-01-01 | 0d |  |  |
| 9 | 1.3 | ***ALL DURATIONS VERY ROUGH ESTIMATES*** | milestone | 0d | 2006-01-01 | 2006-01-01 | 0d |  |  |
| 10 | 1.4 | ***PLEASE USE THIS DOCUMENT ONLY AS A STARTING POINT FOR YOUR PLANNING*** | milestone | 0d | 2006-01-01 | 2006-01-01 | 0d |  |  |
| 11 | 1.5 | This represents experience from hundreds of WebSphere Portal Projects | milestone | 0d | 2006-01-01 | 2006-01-01 | 0d |  |  |
| 12 | 1.6 | However, each portal is unique, and you should review each task to determine the applicability and duration for your portal project | milestone | 0d | 2006-01-01 | 2006-01-01 | 0d |  |  |
| 13 | 1.7 | Your mileage may vary; batteries not included | milestone | 0d | 2006-01-01 | 2006-01-01 | 0d |  |  |
| 14 | 1.8 | For consultanting help, consider http://www.lotus.com/services | milestone | 0d | 2006-01-01 | 2006-01-01 | 0d |  |  |
| 15 | 2 | **Pre-reqs** |  | 10d? | 2006-01-02 | 2006-01-13 | 0d |  |  |
| 16 | 2.1 | ROI Study |  | 10d? | 2006-01-02 | 2006-01-13 | 0d |  |  |
| 17 | 2.2 | IBM Solution Assurance Review |  | 5d? | 2006-01-02 | 2006-01-06 | 0d |  |  |
| 18 | 3 | **Project Startup** |  | 17d? | 2006-01-01 | 2006-01-24 | 0d |  | 568h |
| 19 | 3.1 | **Objectives** |  | 2d? | 2006-01-02 | 2006-01-03 | 0d |  | 56h |
| 20 | 3.1.1 | Identify Stakeholders |  | 0.5d? | 2006-01-02 | 2006-01-02 | 0d | Project Owner | 4h |
| 21 | 3.1.2 | Identify Primary Objectives |  | 2d? | 2006-01-02 | 2006-01-03 | 0d | Project Owner | 16h |
| 22 | 3.1.3 | Identify Key Constaints |  | 0.5d? | 2006-01-02 | 2006-01-02 | 0d | Project Owner | 4h |
| 23 | 3.1.4 | Objectives Review |  | 2d | 2006-01-02 | 2006-01-03 | 0d | Project Owner; IBM Services | 32h |
| 24 | 3.2 | **Staffing** |  | 5d? | 2006-01-01 | 2006-01-06 | 0d |  | 312h |
| 25 | 3.2.1 | Identify Project Manager | milestone | 0d | 2006-01-01 | 2006-01-01 | 0d | Project Owner |  |

Notes:
- 10: This plan does not include generic software processes such as HW, SW, network, and consulting marketing, sales, demo, proof of concepts, contracts, etc.
- 12: Note: More overlapping of tasks is possible...for instance, starting portlet development while design issues are still being resolved. This project schedule does not attempt to minimize the duration with such overlapping since that causes some degree of re-work...and we know you will be tempted to overlap too much anyway to meet your schedule deadlines. Good luck.

| ID | WBS | Task | Type | Duration | Start | Finish | Predecessors | Total slack | Resources | Work |
| --- | --- | --- | --- | --- | --- | --- | --- | --- | --- | --- |
| 26 | 3.2.2 | **Technical Team** |  | 5d? | 2006-01-02 | 2006-01-06 |  | 0d |  | 312h |
| 27 | 3.2.2.1 | Skills Assessment |  | 2d? | 2006-01-02 | 2006-01-03 |  | 0d | IBM Services; Project Manager | 32h |
| 28 | 3.2.2.2 | **Skills Enhancement** |  | 5d | 2006-01-02 | 2006-01-06 |  | 0d |  | 280h |
| 29 | 3.2.2.2.1 | **Developer Education** |  | 5d | 2006-01-02 | 2006-01-06 |  | 0d |  | 200h |
| 30 | 3.2.2.2.1.1 | OO and Java for Developers |  | 5d | 2006-01-02 | 2006-01-06 |  | 0d | Developers | 40h |
| 31 | 3.2.2.2.1.2 | WebSphere Application Server |  | 5d | 2006-01-02 | 2006-01-06 |  | 0d | Developers | 40h |
| 32 | 3.2.2.2.1.3 | **WebSphere Portal Development** |  | 5d | 2006-01-02 | 2006-01-06 |  | 0d |  | 80h |
| 33 | 3.2.2.2.1.3.1 | Rational Application Developer / Eclipse |  | 5d | 2006-01-02 | 2006-01-06 |  | 0d | Developers | 40h |
| 34 | 3.2.2.2.1.3.2 | JSR 168 |  | 2d | 2006-01-02 | 2006-01-03 |  | 0d | Developers | 16h |
| 35 | 3.2.2.2.1.3.3 | Themes & Skins |  | 1d | 2006-01-02 | 2006-01-02 |  | 0d | Developers | 8h |
| 36 | 3.2.2.2.1.3.4 | Struts or JSF, if desired |  | 2d | 2006-01-02 | 2006-01-03 |  | 0d | Developers | 16h |
| 37 | 3.2.2.2.1.4 | IBM Workplace Web Content Management |  | 5d | 2006-01-02 | 2006-01-06 |  | 0d | Development Lead | 40h |
| 38 | 3.2.2.2.2 | **Operations Education** |  | 5d | 2006-01-02 | 2006-01-06 |  | 0d |  | 80h |
| 39 | 3.2.2.2.2.1 | WebSphere Application Server |  | 5d | 2006-01-02 | 2006-01-06 |  | 0d | Infrastructure Lead | 40h |
| 40 | 3.2.2.2.2.2 | WebSphere Portal Server |  | 5d | 2006-01-02 | 2006-01-06 |  | 0d | Infrastructure Lead | 40h |
| 41 | 3.3 | **Project Management** |  | 17d | 2006-01-01 | 2006-01-24 |  | 0d |  | 200h |
| 42 | 3.3.1 | Determine status reporting approach |  | 3d | 2006-01-02 | 2006-01-04 |  | 0d | Project Owner; Project Manager | 48h |
| 43 | 3.3.2 | **Create/Track Microsoft Project Plan** |  | 17d | 2006-01-01 | 2006-01-24 |  | 0d |  | 152h |
| 44 | 3.3.2.1 | Define Plan |  | 15d | 2006-01-02 | 2006-01-20 |  | 0d | Project Manager | 120h |
| 45 | 3.3.2.2 | Review with IBM |  | 2d | 2006-01-23 | 2006-01-24 | 44 | 0d | Project Manager; IBM Services | 32h |
| 46 | 3.3.2.3 | Identify key milesteons/interim demos/executive checkpoints | milestone | 0d | 2006-01-01 | 2006-01-01 |  | 0d | Project Owner; Project Manager |  |
| 47 | 4 | **Solution Definition** |  | 15d? | 2006-01-01 | 2006-01-20 |  | 0d |  | 548h |
| 48 | 4.1 | Generate business requirements |  | 4h | 2006-01-02 | 2006-01-02 |  | 0d |  |  |
| 49 | 4.2 | Generate performance requirements |  | 1h | 2006-01-02 | 2006-01-02 |  | 0d |  |  |
| 50 | 4.3 | Review gotchas |  | 1h | 2006-01-02 | 2006-01-02 |  | 0d |  |  |
| 51 | 4.4 | Develop security policy |  | 3h | 2006-01-02 | 2006-01-02 |  | 0d | Architect; Project Manager | 6h |
| 52 | 4.5 | Design WCM architecture and taxonomy |  | 3h | 2006-01-02 | 2006-01-02 |  | 0d | Architect; Project Manager | 6h |
| 53 | 4.6 | Design search architecture |  | 3h | 2006-01-02 | 2006-01-02 |  | 0d | Architect; Project Manager | 6h |
| 54 | 4.7 | UI design (wireframes and portlet sourcing) |  | 3h | 2006-01-02 | 2006-01-02 |  | 0d | Architect; Project Manager | 6h |
| 55 | 4.8 | Personalization design |  | 3h | 2006-01-02 | 2006-01-02 |  | 0d | Architect; Project Manager | 6h |

Notes:
- 29: Fewer courses might be needed, depending on the skills assessments.
- 41: The actual number of days for project management will be very specific to the individual project.

| ID | WBS | Task | Type | Duration | Start | Finish | Total slack | Resources | Work |
| --- | --- | --- | --- | --- | --- | --- | --- | --- | --- |
| 56 | 4.9 | **Development environment** |  | 2d? | 2006-01-02 | 2006-01-03 | 0d | Architect; Project Manager | 32h |
| 57 | 4.9.1 | Capacity planning |  | 2d | 2006-01-02 | 2006-01-03 | 0d |  |  |
| 58 | 4.9.2 | Backup and recovery planning |  | 1d? | 2006-01-02 | 2006-01-02 | 0d |  |  |
| 59 | 4.10 | **QA environment** |  | 1d? | 2006-01-02 | 2006-01-02 | 0d | Architect; Project Manager | 16h |
| 60 | 4.10.1 | Complete IBM Workload Estimator for iSeries |  | 1d? | 2006-01-02 | 2006-01-02 | 0d |  |  |
| 61 | 4.10.2 | Backup and recovery planning |  | 1d? | 2006-01-02 | 2006-01-02 | 0d |  |  |
| 62 | 4.11 | **Production environment** |  | 1d? | 2006-01-02 | 2006-01-02 | 0d | Architect; Project Manager | 16h |
| 63 | 4.11.1 | Complete IBM Workload Estimator for iSeries |  | 1d? | 2006-01-02 | 2006-01-02 | 0d |  |  |
| 64 | 4.11.2 | Backup and recovery planning |  | 1d? | 2006-01-02 | 2006-01-02 | 0d |  |  |
| 65 | 4.12 | Create software topology diagram(s) |  | 1d? | 2006-01-02 | 2006-01-02 | 0d |  |  |
| 66 | 4.13 | Create hardware topology diagram(s) |  | 3h | 2006-01-02 | 2006-01-02 | 0d | Architect; Project Manager | 6h |
| 67 | 4.14 | Create installation procedure |  | 1d? | 2006-01-02 | 2006-01-02 | 0d |  |  |
| 68 | 4.15 | Identify Risks / Open Issues |  | 1.5d | 2006-01-02 | 2006-01-03 | 0d | Architect; Project Manager | 24h |
| 69 | 4.16 | Document Key Decisions and Recommendations |  | 3d | 2006-01-02 | 2006-01-04 | 0d | Architect; Project Manager | 48h |
| 70 | 4.17 | Review and Approval | milestone | 2d | 2006-01-02 | 2006-01-03 | 0d | Project Owner | 16h |
| 71 | 4.18 | **Software Products Selected** |  | 1d? | 2006-01-01 | 2006-01-02 | 0d | Architect | 8h |
| 72 | 4.18.1 | Review Software requirements for Portal |  | 1d? | 2006-01-02 | 2006-01-02 | 0d |  |  |
| 73 | 4.18.2 | WebSphere Portal Express | milestone | 0d | 2006-01-01 | 2006-01-01 | 0d |  |  |
| 74 | 4.18.3 | WebSphere Portal Express Plus | milestone | 0d | 2006-01-01 | 2006-01-01 | 0d |  |  |
| 75 | 4.18.4 | **WebSphere Portal Enable** |  | 0d | 2006-01-01 | 2006-01-01 | 0d |  |  |
| 76 | 4.18.4.1 | IBM HTTP Server | milestone | 0d | 2006-01-01 | 2006-01-01 | 0d |  |  |
| 77 | 4.18.4.2 | WebSphere Application Server | milestone | 0d | 2006-01-01 | 2006-01-01 | 0d |  |  |
| 78 | 4.18.4.3 | WebSphere Portal | milestone | 0d | 2006-01-01 | 2006-01-01 | 0d |  |  |
| 79 | 4.18.4.4 | Rational Application Developer | milestone | 0d | 2006-01-01 | 2006-01-01 | 0d |  |  |
| 80 | 4.18.4.5 | WebSphere Portal Application Integrator | milestone | 0d | 2006-01-01 | 2006-01-01 | 0d |  |  |
| 81 | 4.18.4.6 | Portal Document Manager | milestone | 0d | 2006-01-01 | 2006-01-01 | 0d |  |  |
| 82 | 4.18.4.7 | Lightweight Office Components | milestone | 0d | 2006-01-01 | 2006-01-01 | 0d |  |  |
| 83 | 4.18.4.8 | Workplace Web Content Management | milestone | 0d | 2006-01-01 | 2006-01-01 | 0d |  |  |
| 84 | 4.18.4.9 | WebSphere Personalization | milestone | 0d | 2006-01-01 | 2006-01-01 | 0d |  |  |
| 85 | 4.18.4.10 | Portal Search Engine | milestone | 0d | 2006-01-01 | 2006-01-01 | 0d |  |  |
| 86 | 4.18.4.11 | IBM Directory Server | milestone | 0d | 2006-01-01 | 2006-01-01 | 0d |  |  |
| 87 | 4.18.4.12 | Portal Database (e.g. DB2) | milestone | 0d | 2006-01-01 | 2006-01-01 | 0d |  |  |

Notes:
- 71: Delete, modify, or add products as appropriate. The "duration" for each should be zero as all are assumed to be covered in the architecture and design workshop.

| ID | WBS | Task | Type | Duration | Start | Finish | Total slack | Resources | Work |
| --- | --- | --- | --- | --- | --- | --- | --- | --- | --- |
| 88 | 4.18.5 | **WebSphere Portal Extend** |  | 0d | 2006-01-01 | 2006-01-01 | 0d |  |  |
| 89 | 4.18.5.1 | Best Practice: Don't include too much in first release! See note. | milestone | 0d | 2006-01-01 | 2006-01-01 | 0d |  |  |
| 90 | 4.18.5.2 | Extended Search | milestone | 0d | 2006-01-01 | 2006-01-01 | 0d |  |  |
| 91 | 4.18.5.3 | Lotus Instance Messaging (Sametime) | milestone | 0d | 2006-01-01 | 2006-01-01 | 0d |  |  |
| 92 | 4.18.5.4 | Lotus Team Workplaces (Quickplaces) | milestone | 0d | 2006-01-01 | 2006-01-01 | 0d |  |  |
| 93 | 4.18.5.5 | Collaboration Center | milestone | 0d | 2006-01-01 | 2006-01-01 | 0d |  |  |
| 94 | 4.18.5.6 | Lotus Collaborative Services APIs / Online Awareness | milestone | 0d | 2006-01-01 | 2006-01-01 | 0d |  |  |
| 95 | 4.18.5.7 | Tivoli Web Site Analzyer | milestone | 0d | 2006-01-01 | 2006-01-01 | 0d |  |  |
| 96 | 4.18.6 | **Complementary IBM Products** |  | 0d | 2006-01-01 | 2006-01-01 | 0d |  |  |
| 97 | 4.18.6.1 | WebSphere Edge Server | milestone | 0d | 2006-01-01 | 2006-01-01 | 0d |  |  |
| 98 | 4.18.6.2 | Tivoli Access Manager | milestone | 0d | 2006-01-01 | 2006-01-01 | 0d |  |  |
| 99 | 4.18.6.3 | Tivoli Identity Manager | milestone | 0d | 2006-01-01 | 2006-01-01 | 0d |  |  |
| 100 | 4.18.6.4 | IBM (DB2) Content Manager | milestone | 0d | 2006-01-01 | 2006-01-01 | 0d |  |  |
| 101 | 4.18.6.5 | Business Process Choreographer | milestone | 0d | 2006-01-01 | 2006-01-01 | 0d |  |  |
| 102 | 4.18.6.6 | WebSphere Business Integration (for SOA) | milestone | 0d | 2006-01-01 | 2006-01-01 | 0d |  |  |
| 103 | 4.18.6.7 | WebSphere Translation Server | milestone | 0d | 2006-01-01 | 2006-01-01 | 0d |  |  |
| 104 | 4.18.6.8 | WebSphere Studio Application Monitor | milestone | 0d | 2006-01-01 | 2006-01-01 | 0d |  |  |
| 105 | 4.18.7 | **Complementary Third-Party Products** |  | 0d | 2006-01-01 | 2006-01-01 | 0d |  |  |
| 106 | 4.18.7.1 | WebSphere Portlet Factory | milestone | 0d | 2006-01-01 | 2006-01-01 | 0d |  |  |
| 107 | 4.18.7.2 | External Security Manager | milestone | 0d | 2006-01-01 | 2006-01-01 | 0d |  |  |
| 108 | 4.18.7.3 | Load Testing Tool | milestone | 0d | 2006-01-01 | 2006-01-01 | 0d |  |  |
| 109 | 4.18.7.4 | Performance Monitoring and Alert Tool | milestone | 0d | 2006-01-01 | 2006-01-01 | 0d |  |  |
| 110 | 4.19 | **Hardware Selected** |  | 1d? | 2006-01-01 | 2006-01-02 | 0d | Architect | 8h |
| 111 | 4.19.1 | Review hardware requirements for Portal |  | 1d? | 2006-01-02 | 2006-01-02 | 0d |  |  |

Notes:
- 89: Although the organization may select Extend, our recommendation is that the functions in Enable are best for the initial pilot phase, with maybe one aspect of Extend investigated during the pilot phase.

| ID | WBS | Task | Type | Duration | Start | Finish | Total slack | Resources | Work |
| --- | --- | --- | --- | --- | --- | --- | --- | --- | --- |
| 112 | 4.19.2 | **Development Environment** |  | 0d | 2006-01-01 | 2006-01-01 | 0d |  |  |
| 113 | 4.19.2.1 | Portal Server(s): Operating System, Memory, Processor, etc. | milestone | 0d | 2006-01-01 | 2006-01-01 | 0d |  |  |
| 114 | 4.19.2.2 | Collaboration Server(s) | milestone | 0d | 2006-01-01 | 2006-01-01 | 0d |  |  |
| 115 | 4.19.2.3 | Database Servers | milestone | 0d | 2006-01-01 | 2006-01-01 | 0d |  |  |
| 116 | 4.19.2.4 | Edge Servers | milestone | 0d | 2006-01-01 | 2006-01-01 | 0d |  |  |
| 117 | 4.19.2.5 | Directory Servers | milestone | 0d | 2006-01-01 | 2006-01-01 | 0d |  |  |
| 118 | 4.19.2.6 | Other Servers | milestone | 0d | 2006-01-01 | 2006-01-01 | 0d |  |  |
| 119 | 4.19.3 | **Staging Environment** |  | 0d | 2006-01-01 | 2006-01-01 | 0d |  |  |
| 120 | 4.19.3.1 | Portal Server(s): Operating System, Memory, Processor, etc. | milestone | 0d | 2006-01-01 | 2006-01-01 | 0d |  |  |
| 121 | 4.19.3.2 | Collaboration Server(s) | milestone | 0d | 2006-01-01 | 2006-01-01 | 0d |  |  |
| 122 | 4.19.3.3 | Database Servers | milestone | 0d | 2006-01-01 | 2006-01-01 | 0d |  |  |
| 123 | 4.19.3.4 | Edge Servers | milestone | 0d | 2006-01-01 | 2006-01-01 | 0d |  |  |
| 124 | 4.19.3.5 | Directory Servers | milestone | 0d | 2006-01-01 | 2006-01-01 | 0d |  |  |
| 125 | 4.19.3.6 | Other Servers | milestone | 0d | 2006-01-01 | 2006-01-01 | 0d |  |  |
| 126 | 4.19.4 | **Production Environment** |  | 0d | 2006-01-01 | 2006-01-01 | 0d |  |  |
| 127 | 4.19.4.1 | Portal Server(s): Operating System, Memory, Processor, etc. | milestone | 0d | 2006-01-01 | 2006-01-01 | 0d |  |  |
| 128 | 4.19.4.2 | Collaboration Server(s) | milestone | 0d | 2006-01-01 | 2006-01-01 | 0d |  |  |
| 129 | 4.19.4.3 | Database Servers | milestone | 0d | 2006-01-01 | 2006-01-01 | 0d |  |  |
| 130 | 4.19.4.4 | Edge Servers | milestone | 0d | 2006-01-01 | 2006-01-01 | 0d |  |  |
| 131 | 4.19.4.5 | Directory Servers | milestone | 0d | 2006-01-01 | 2006-01-01 | 0d |  |  |
| 132 | 4.19.4.6 | Other Servers | milestone | 0d | 2006-01-01 | 2006-01-01 | 0d |  |  |
| 133 | 4.20 | **Post Workshop Planning and Design** |  | 15d | 2006-01-02 | 2006-01-20 | 0d |  | 344h |
| 134 | 4.20.1 | Scope and Propose Services |  | 2d | 2006-01-02 | 2006-01-03 | 0d | Project Manager; IBM Services | 32h |
| 135 | 4.20.2 | Create draft milestone plan (update this mpp) |  | 3d | 2006-01-02 | 2006-01-04 | 0d | Project Manager | 24h |

| ID | WBS | Task | Type | Duration | Start | Finish | Total slack | Resources | Work |
| --- | --- | --- | --- | --- | --- | --- | --- | --- | --- |
| 136 | 4.20.3 | **Detailed design documentation** |  | 15d | 2006-01-02 | 2006-01-20 | 0d |  | 240h |
| 137 | 4.20.3.1 | Phase 0-2 (Pilot) |  | 15d | 2006-01-02 | 2006-01-20 | 0d | Architect | 120h |
| 138 | 4.20.3.2 | Phase 3-4 (Release) |  | 15d | 2006-01-02 | 2006-01-20 | 0d | Architect | 120h |
| 139 | 4.20.4 | Review and approval of detailed design |  | 3d | 2006-01-02 | 2006-01-04 | 0d | Architect; Project Manager | 48h |
| 140 | 5 | **Establish Project Standards / Best Practices** |  | 0.5d | 2006-01-02 | 2006-01-02 | 0d |  | 40h |
| 141 | 5.1 | Establish Change Management Procedures |  | 0.5d | 2006-01-02 | 2006-01-02 | 0d | Project Manager; Development Lead | 8h |
| 142 | 5.2 | Establish Documentation Standards |  | 0.5d | 2006-01-02 | 2006-01-02 | 0d | Project Manager; Development Lead | 8h |
| 143 | 5.3 | Establish Development Standards |  | 0.5d | 2006-01-02 | 2006-01-02 | 0d | Development Lead | 4h |
| 144 | 5.4 | Document Development Procedures |  | 0.5d | 2006-01-02 | 2006-01-02 | 0d | Development Lead | 4h |
| 145 | 5.5 | Establish Testing Standards |  | 0.5d | 2006-01-02 | 2006-01-02 | 0d | Test Lead | 4h |
| 146 | 5.6 | Establish Deployment Standards |  | 0.5d | 2006-01-02 | 2006-01-02 | 0d | Infrastructure Lead | 4h |
| 147 | 5.7 | Summarize and review in Project Standards document |  | 0.5d | 2006-01-02 | 2006-01-02 | 0d | Architect; Project Manager | 8h |
| 148 | 6 | **Environment Setup (Dev, QA, Prod)** |  | 20d? | 2006-01-01 | 2006-01-27 | 0d |  | 1132h |
| 149 | 6.1 | Document Directory (LDAP) Schema and Design |  | 20d? | 2006-01-02 | 2006-01-27 | 0d | Infrastructure Lead | 160h |
| 150 | 6.2 | **Establish Development Environment** |  | 13d? | 2006-01-01 | 2006-01-18 | 0d |  | 220h |
| 151 | 6.2.1 | Procure Hardware | milestone | 0d | 2006-01-01 | 2006-01-01 | 0d | Project Owner |  |
| 152 | 6.2.2 | Install Hardware |  | 5d | 2006-01-02 | 2006-01-06 | 0d | Project Owner | 40h |
| 153 | 6.2.3 | Procure Software | milestone | 0d | 2006-01-01 | 2006-01-01 | 0d | Project Owner |  |
| 154 | 6.2.4 | **Build Development Infrastructure** |  | 2d? | 2006-01-02 | 2006-01-03 | 0d |  | 64h |
| 155 | 6.2.4.1 | **Prepare the iSeries machine** |  | 1d? | 2006-01-02 | 2006-01-02 | 0d |  | 8h |
| 156 | 6.2.4.1.1 | Install Operating System |  | 1d | 2006-01-02 | 2006-01-02 | 0d | Development Lead | 8h |
| 157 | 6.2.4.1.2 | Determine cumulative PTF package required |  | 1d? | 2006-01-02 | 2006-01-02 | 0d |  |  |
| 158 | 6.2.4.2 | Install Development Repository |  | 1d | 2006-01-02 | 2006-01-02 | 0d | Development Lead | 8h |
| 159 | 6.2.4.3 | Configure Development Repository |  | 2d | 2006-01-02 | 2006-01-03 | 0d | Development Lead | 16h |
| 160 | 6.2.4.4 | Install HTTP Server |  | 1d | 2006-01-02 | 2006-01-02 | 0d | Development Lead | 8h |
| 161 | 6.2.4.5 | Install Portal Database |  | 1d | 2006-01-02 | 2006-01-02 | 0d | Development Lead | 8h |
| 162 | 6.2.4.6 | Install Directory Server |  | 1d | 2006-01-02 | 2006-01-02 | 0d | Development Lead | 8h |
| 163 | 6.2.4.7 | Install Application Server/Portal Server |  | 1d | 2006-01-02 | 2006-01-02 | 0d | Development Lead | 8h |

Notes:
- 140: The actual amount of time each of the standards takes to document depends largely on where the organization is on the Software Engineering Institute's CMM scale. (See http://www.sei.cmu.edu/.) Also, the calendar time this supertask takes depends on how much simultaneity can be achieved in the subtasks.
- 149: The duration is highly dependent on how far along an organization is in its road to having a directory architecture and infrastructure in place.

| ID | WBS | Task | Type | Duration | Start | Finish | Predecessors | Total slack | Resources | Work |
| --- | --- | --- | --- | --- | --- | --- | --- | --- | --- | --- |
| 164 | 6.2.5 | **Create Initial Developer Configuration** |  | 13d | 2006-01-02 | 2006-01-18 |  | 0d |  | 104h |
| 165 | 6.2.5.1 | Install Portal |  | 0.5d | 2006-01-02 | 2006-01-02 |  | 0d | Development Lead | 4h |
| 166 | 6.2.5.2 | Configure connection to Portal Database |  | 0.5d | 2006-01-02 | 2006-01-02 | 165 | 0d | Development Lead | 4h |
| 167 | 6.2.5.3 | Configure connection to Directory Server |  | 0.5d | 2006-01-03 | 2006-01-03 | 166 | 0d | Development Lead | 4h |
| 168 | 6.2.5.4 | Install WebSphere Studio |  | 0.5d | 2006-01-03 | 2006-01-03 | 167 | 0d | Development Lead | 4h |
| 169 | 6.2.5.5 | Confirm install |  | 1d | 2006-01-04 | 2006-01-04 | 168 | 0d | Development Lead | 8h |
| 170 | 6.2.5.6 | Replicate to all developers (1-2 days/developer) |  | 10d | 2006-01-05 | 2006-01-18 | 169 | 0d | Developers | 80h |
| 171 | 6.2.6 | **Confirm Installation** |  | 0.25d | 2006-01-02 | 2006-01-02 |  | 0d |  | 12h |
| 172 | 6.2.6.1 | Confirm DB connections |  | 1h | 2006-01-02 | 2006-01-02 |  | 0d | Infrastructure Lead; Development Lead | 2h |
| 173 | 6.2.6.2 | Confirm WAS (e.g. snoop servlet) |  | 1h | 2006-01-02 | 2006-01-02 |  | 0d | Infrastructure Lead; Development Lead | 2h |
| 174 | 6.2.6.3 | Confirm Portal Login |  | 1h | 2006-01-02 | 2006-01-02 |  | 0d | Infrastructure Lead; Development Lead | 2h |
| 175 | 6.2.6.4 | Use admin to create/deploy places and portlets |  | 1h | 2006-01-02 | 2006-01-02 |  | 0d | Infrastructure Lead; Development Lead | 2h |
| 176 | 6.2.6.5 | Confirm basic portlet function with user login |  | 1h | 2006-01-02 | 2006-01-02 |  | 0d | Infrastructure Lead; Development Lead | 2h |
| 177 | 6.2.6.6 | Confirm security/authorizations work |  | 1h | 2006-01-02 | 2006-01-02 | 176 | 0d | Infrastructure Lead; Development Lead | 2h |
| 178 | 6.3 | **Establish QA Environment** |  | 10d? | 2006-01-01 | 2006-01-13 |  | 0d |  | 192h |
| 179 | 6.3.1 | Procure Hardware | milestone | 0d | 2006-01-01 | 2006-01-01 |  | 0d | Project Owner |  |
| 180 | 6.3.2 | Procure Software | milestone | 0d | 2006-01-01 | 2006-01-01 |  | 0d | Project Owner |  |
| 181 | 6.3.3 | **Prepare the iSeries machine** |  | 1d? | 2006-01-02 | 2006-01-02 |  | 0d |  | 8h |
| 182 | 6.3.3.1 | Install Operating System |  | 1d | 2006-01-02 | 2006-01-02 |  | 0d | Infrastructure Lead | 8h |
| 183 | 6.3.3.2 | Determine cumulative PTF package required |  | 1d? | 2006-01-02 | 2006-01-02 |  | 0d |  |  |
| 184 | 6.3.4 | Install HTTP Server |  | 1d | 2006-01-02 | 2006-01-02 |  | 0d | Infrastructure Lead | 8h |
| 185 | 6.3.5 | Install Portal Database Server |  | 1d | 2006-01-02 | 2006-01-02 |  | 0d | Infrastructure Lead | 8h |
| 186 | 6.3.6 | Install Directory Server |  | 1d | 2006-01-02 | 2006-01-02 |  | 0d | Infrastructure Lead | 8h |
| 187 | 6.3.7 | Install Application Server/Portal Server |  | 1d | 2006-01-02 | 2006-01-02 |  | 0d | Infrastructure Lead | 8h |
| 188 | 6.3.8 | Configure Portal Server to use DB and LDAP |  | 1d | 2006-01-02 | 2006-01-02 |  | 0d | Infrastructure Lead | 8h |
| 189 | 6.3.9 | Configure Cloning/Clustering for WAS |  | 10d | 2006-01-02 | 2006-01-13 |  | 0d | Infrastructure Lead | 80h |
| 190 | 6.3.10 | Configure Cloning/Clustering for Sametime/QuickPlace |  | 3d | 2006-01-02 | 2006-01-04 |  | 0d | Infrastructure Lead | 24h |
| 191 | 6.3.11 | Install/configure Performance Tool |  | 2d | 2006-01-02 | 2006-01-03 |  | 0d | Infrastructure Lead | 16h |
| 192 | 6.3.12 | Best Practice: Baseline your performance before application is installed | milestone | 0d | 2006-01-01 | 2006-01-01 |  | 0d |  |  |
| 193 | 6.3.13 | Confirm Installation for each server | milestone | 3d? | 2006-01-02 | 2006-01-04 |  | 0d | Infrastructure Lead | 24h |

| ID | WBS | Task | Type | Duration | Start | Finish | Total slack | Resources | Work |
| --- | --- | --- | --- | --- | --- | --- | --- | --- | --- |
| 194 | 6.4 | **Establish Production Environment** |  | 10d? | 2006-01-01 | 2006-01-13 | 0d |  | 560h |
| 195 | 6.4.1 | Procure Hardware | milestone | 0d? | 2006-01-01 | 2006-01-01 | 0d | Project Owner |  |
| 196 | 6.4.2 | Install Hardware |  | 1d? | 2006-01-02 | 2006-01-02 | 0d | Project Owner | 8h |
| 197 | 6.4.3 | Procure Software |  | 1d? | 2006-01-02 | 2006-01-02 | 0d | Project Owner | 8h |
| 198 | 6.4.4 | **Install Software** |  | 10d? | 2006-01-01 | 2006-01-13 | 0d |  | 336h |
| 199 | 6.4.4.1 | Develop/Test Install Guide/Scripts (Ant) |  | 5d | 2006-01-02 | 2006-01-06 | 0d | Infrastructure Lead | 40h |
| 200 | 6.4.4.2 | **Install Servers** |  | 5d? | 2006-01-01 | 2006-01-06 | 0d |  | 160h |
| 201 | 6.4.4.2.1 | Install Operating System |  | 1d | 2006-01-02 | 2006-01-02 | 0d | Infrastructure Lead | 8h |
| 202 | 6.4.4.2.2 | Install HTTP Server |  | 1d | 2006-01-02 | 2006-01-02 | 0d | Infrastructure Lead | 8h |
| 203 | 6.4.4.2.3 | Install Portal Database Server |  | 1d | 2006-01-02 | 2006-01-02 | 0d | Infrastructure Lead | 8h |
| 204 | 6.4.4.2.4 | Install Directory Server |  | 1d | 2006-01-02 | 2006-01-02 | 0d | Infrastructure Lead | 8h |
| 205 | 6.4.4.2.5 | Install WebSphere Application Server/Portal Server |  | 1d | 2006-01-02 | 2006-01-02 | 0d | Infrastructure Lead | 8h |
| 206 | 6.4.4.2.6 | Install Extended Search |  | 3d | 2006-01-02 | 2006-01-04 | 0d | Infrastructure Lead | 24h |
| 207 | 6.4.4.2.7 | Install Lotus Collaboration Servers (Sametime and QuickPlace) |  | 4d | 2006-01-02 | 2006-01-05 | 0d | Infrastructure Lead | 32h |
| 208 | 6.4.4.2.8 | Install Collaboration Center |  | 2d | 2006-01-02 | 2006-01-03 | 0d | Infrastructure Lead | 16h |
| 209 | 6.4.4.2.9 | Install Tivoli Web Site Analzyer |  | 1d | 2006-01-02 | 2006-01-02 | 0d | Infrastructure Lead | 8h |
| 210 | 6.4.4.2.10 | Install Tivoli Access Manager TAI on WAS |  | 5d | 2006-01-02 | 2006-01-06 | 0d | Infrastructure Lead | 40h |
| 211 | 6.4.4.2.11 | Install Other Software Components | milestone | 0d? | 2006-01-01 | 2006-01-01 | 0d | Infrastructure Lead |  |
| 212 | 6.4.4.3 | Configure Clustering for WAS/WP |  | 10d | 2006-01-02 | 2006-01-13 | 0d | Infrastructure Lead | 80h |
| 213 | 6.4.4.4 | Configure Clustering for Sametime/QuickPlace |  | 2d | 2006-01-02 | 2006-01-03 | 0d | Infrastructure Lead | 16h |
| 214 | 6.4.4.5 | Confirm Installation for each server |  | 5d | 2006-01-02 | 2006-01-06 | 0d | Infrastructure Lead | 40h |
| 215 | 6.4.5 | Deploy Tested Portal/Portlets |  | 5d | 2006-01-02 | 2006-01-06 | 0d | Development Lead; Test Lead; Infrastructure Lead | 120h |
| 216 | 6.4.6 | Document Operator Procedures |  | 5d | 2006-01-02 | 2006-01-06 | 0d | Infrastructure Lead | 40h |
| 217 | 6.4.7 | Operator Training |  | 3d | 2006-01-02 | 2006-01-04 | 0d | Infrastructure Lead; Project Owner | 48h |

Notes:
- 210: Assumes that Tivoli Access Manager is already install. Installation of TAM is outside the scope of this project.
- 211: There may be other software selected for the production solution, including legacy connectors, ERP systems, WebSphere MQ, etc. This task is highly dependent on the specific project.

| ID | WBS | Task | Type | Duration | Start | Finish | Predecessors | Total slack | Resources | Work |
| --- | --- | --- | --- | --- | --- | --- | --- | --- | --- | --- |
| 218 | 7 | **Pilot Development (build basic function)** |  | 15d? | 2006-01-01 | 2006-01-20 |  | 0d |  | 768h |
| 219 | 7.1 | Objective: Implement out-of-the-box function & limited custom function | milestone | 0d | 2006-01-01 | 2006-01-01 |  | 0d |  |  |
| 220 | 7.2 | **Design** |  | 5d | 2006-01-02 | 2006-01-06 |  | 0d |  | 184h |
| 221 | 7.2.1 | Assign custom development tasks |  | 2.5d | 2006-01-02 | 2006-01-04 |  | 2.5d | Project Manager | 20h |
| 222 | 7.2.2 | **Document design(s) for custom portlets** |  | 2d | 2006-01-02 | 2006-01-03 |  | 3d |  | 20h |
| 223 | 7.2.2.1 | Select Design Approach, Framework (e.g. Struts), and Tools |  | 2d | 2006-01-02 | 2006-01-03 |  | 3d | Developers | 16h |
| 224 | 7.2.2.2 | Best Practice: Complete Portlet Sourcing Worksheet |  | 0.5d | 2006-01-02 | 2006-01-02 |  | 4.5d | Developers | 4h |
| 225 | 7.2.3 | Document design for changes to backend systems |  | 5d | 2006-01-02 | 2006-01-06 |  | 0d | Architect | 40h |
| 226 | 7.2.4 | Document design for UI including themes and skins |  | 2d | 2006-01-02 | 2006-01-03 |  | 3d | Development Lead | 16h |
| 227 | 7.2.5 | Document use/test cases |  | 5d | 2006-01-02 | 2006-01-06 |  | 0d | Test Lead | 40h |
| 228 | 7.2.6 | Review designs |  | 2d | 2006-01-02 | 2006-01-03 |  | 3d | Development Lead; Architect; Project Manager | 48h |
| 229 | 7.3 | **Build** |  | 15d | 2006-01-02 | 2006-01-20 |  | 0d |  | 448h |
| 230 | 7.3.1 | **Iterative Development** |  | 15d | 2006-01-02 | 2006-01-20 |  | 0d |  | 448h |
| 231 | 7.3.1.1 | **Develop/test phase 0** |  | 3d | 2006-01-02 | 2006-01-04 |  | 2d |  | 48h |
| 232 | 7.3.1.1.1 | Develop/test out-of-the-box function |  | 3d | 2006-01-02 | 2006-01-04 |  | 2d | Development Lead; Infrastructure Lead | 48h |
| 233 | 7.3.1.2 | **Develop/test phase 1 of custom development** |  | 10d | 2006-01-06 | 2006-01-20 | 220, 231 | 0d |  | 200h |
| 234 | 7.3.1.2.1 | Rebrand Themes & Skins |  | 10d | 2006-01-09 | 2006-01-20 |  | 0d | Development Lead | 80h |
| 235 | 7.3.1.2.2 | **A few (3-5) simple custom portlets of various types** |  | 10d | 2006-01-06 | 2006-01-20 |  | 0d |  | 120h |
| 236 | 7.3.1.2.2.1 | Portlet 1a: (e.g. iFrame) |  | 2d | 2006-01-09 | 2006-01-10 |  | 0d | Developers | 16h |
| 237 | 7.3.1.2.2.2 | Portlet 1b: (e.g. clipping) |  | 3d | 2006-01-09 | 2006-01-11 |  | 0d | Developers | 24h |
| 238 | 7.3.1.2.2.3 | Portlet 1c: (e.g. custom using RAD) |  | 10d | 2006-01-09 | 2006-01-20 |  | 0d | Developers | 80h |
| 239 | 7.3.1.2.2.4 | etc. | milestone | 0d | 2006-01-06 | 2006-01-06 |  | 0d | Developers |  |
| 240 | 7.3.1.3 | **Develop/test phase 2 of custom development** |  | 5d | 2006-01-02 | 2006-01-06 |  | 0d |  | 200h |
| 241 | 7.3.1.3.1 | **5 additional custom portlets** |  | 5d | 2006-01-02 | 2006-01-06 |  | 0d |  | 200h |
| 242 | 7.3.1.3.1.1 | Portlet 2a: |  | 5d | 2006-01-02 | 2006-01-06 |  | 0d | Developers | 40h |
| 243 | 7.3.1.3.1.2 | Portlet 2b: |  | 5d | 2006-01-02 | 2006-01-06 |  | 0d | Developers | 40h |
| 244 | 7.3.1.3.1.3 | Portlet 2c: |  | 5d | 2006-01-02 | 2006-01-06 |  | 0d | Developers | 40h |
| 245 | 7.3.1.3.1.4 | Portlet 2d: |  | 5d | 2006-01-02 | 2006-01-06 |  | 0d | Developers | 40h |
| 246 | 7.3.1.3.1.5 | Portlet 2e: |  | 5d | 2006-01-02 | 2006-01-06 |  | 0d | Developers | 40h |

Notes:
- 218: In some projects, the pilot delivers a majority of function to some users. How much function is delivered to which users is highly specific to a particular project. In our experience it is best if a pilot restricts itself to 3-to-5 different out-of-the-box portlets and 3-to-5 custom portlets with no more than moderate complexity. We would also recommend keeping it to about 3 pages.
- 220: Although this project plan (due to tool limitations) represents the design/build/deployment as a linear process, in fact agile methodologies (such as Extreme Programming) lend themselves well to Portal development. Needless to say, traditional methodologies (such as the Rational Unified Process) can also be used.
- 229: The number of iterations and their content is highly specific to the individual project.

| ID | WBS | Task | Type | Duration | Start | Finish | Predecessors | Total slack | Resources | Work |
| --- | --- | --- | --- | --- | --- | --- | --- | --- | --- | --- |
| 247 | 7.4 | **Integration test** |  | 15d? | 2006-01-02 | 2006-01-20 |  | 0d |  | 120h |
| 248 | 7.4.1 | QA/Integration Testing in Development Environment |  | 15d? | 2006-01-02 | 2006-01-20 |  | 0d | Test Lead | 120h |
| 249 | 7.5 | Demo the Pilot to your executives! | milestone | 1d | 2006-01-02 | 2006-01-02 |  | 0d | Project Owner; Architect | 16h |
| 250 | 8 | **Pilot Release (release basic function)** |  | 10d? | 2006-01-01 | 2006-01-13 |  | 0d |  | 736h |
| 251 | 8.1 | **Test** |  | 10d? | 2006-01-01 | 2006-01-13 |  | 0d |  | 736h |
| 252 | 8.1.1 | **System Test** |  | 10d? | 2006-01-02 | 2006-01-13 |  | 0d |  | 160h |
| 253 | 8.1.1.1 | Execute Use Cases |  | 10d? | 2006-01-02 | 2006-01-13 |  | 0d | Test Lead | 80h |
| 254 | 8.1.1.2 | Develop Backup/Recovery Procedures |  | 5d | 2006-01-02 | 2006-01-06 |  | 0d | Infrastructure Lead | 40h |
| 255 | 8.1.1.3 | Test Backup/Recovery Procedures |  | 5d | 2006-01-02 | 2006-01-06 |  | 0d | Infrastructure Lead | 40h |
| 256 | 8.1.2 | **Performance/Stress Test** |  | 5d | 2006-01-02 | 2006-01-06 |  | 0d |  | 320h |
| 257 | 8.1.2.1 | Develop Performance Scripts |  | 5d | 2006-01-02 | 2006-01-06 |  | 0d | Infrastructure Lead; Test Lead | 80h |
| 258 | 8.1.2.2 | Stress Testing |  | 5d | 2006-01-02 | 2006-01-06 |  | 0d | Infrastructure Lead; Test Lead | 80h |
| 259 | 8.1.2.3 | Failover Testing |  | 5d | 2006-01-02 | 2006-01-06 |  | 0d | Infrastructure Lead; Test Lead | 80h |
| 260 | 8.1.2.4 | Adjust and confirm |  | 5d | 2006-01-02 | 2006-01-06 |  | 0d | Infrastructure Lead; Test Lead | 80h |
| 261 | 8.1.3 | **Deployment** |  | 8d? | 2006-01-01 | 2006-01-11 |  | 0d |  | 256h |
| 262 | 8.1.3.1 | Develop/Test Install Guide/Scripts (ANT) |  | 5d | 2006-01-02 | 2006-01-06 |  | 0d | Infrastructure Lead | 40h |
| 263 | 8.1.3.2 | Deploy Tested Portal/Portlets |  | 5d | 2006-01-02 | 2006-01-06 |  | 0d | Infrastructure Lead | 40h |
| 264 | 8.1.3.3 | Update Operator Procedures |  | 5d | 2006-01-02 | 2006-01-06 |  | 0d | Infrastructure Lead | 40h |
| 265 | 8.1.3.4 | Conduct Operator Training |  | 3d | 2006-01-09 | 2006-01-11 | 264 | 0d | Infrastructure Lead | 24h |
| 266 | 8.1.3.5 | Establish End User Documentation/Training | milestone | 0d? | 2006-01-01 | 2006-01-01 |  | 0d | Project Owner |  |
| 267 | 8.1.3.6 | Deployment Readiness Assessment |  | 3d | 2006-01-02 | 2006-01-04 |  | 0d | Infrastructure Lead; IBM Services | 48h |
| 268 | 8.1.3.7 | Go/No-Go Decision |  | 1d | 2006-01-02 | 2006-01-02 |  | 0d | Project Owner | 8h |
| 269 | 8.1.3.8 | Go Live |  | 1d | 2006-01-02 | 2006-01-02 |  | 0d | Project Owner | 8h |
| 270 | 8.1.3.9 | Issue Management |  | 2d | 2006-01-02 | 2006-01-03 |  | 0d | Project Owner; Project Manager; Architect | 48h |

| ID | WBS | Task | Type | Duration | Start | Finish | Predecessors | Total slack | Resources | Work |
| --- | --- | --- | --- | --- | --- | --- | --- | --- | --- | --- |
| 271 | 9 | **Production Release** |  | 15d? | 2006-01-01 | 2006-01-20 |  | 0d |  | 1280h |
| 272 | 9.1 | **Design** |  | 5d | 2006-01-02 | 2006-01-06 |  | 0d |  | 224h |
| 273 | 9.1.1 | Assign custom development tasks |  | 2.5d | 2006-01-02 | 2006-01-04 |  | 0d | Project Manager | 20h |
| 274 | 9.1.2 | **Document design(s) for custom portlets** |  | 2d | 2006-01-02 | 2006-01-03 |  | 0d |  | 20h |
| 275 | 9.1.2.1 | Select Design Approach |  | 2d | 2006-01-02 | 2006-01-03 |  | 0d | Developers | 16h |
| 276 | 9.1.2.2 | Best Practice: Complete Portlet Sourcing Worksheet |  | 0.5d | 2006-01-02 | 2006-01-02 |  | 0d | Developers | 4h |
| 277 | 9.1.3 | Document design for changes to backend systems |  | 5d | 2006-01-02 | 2006-01-06 |  | 0d | Architect | 40h |
| 278 | 9.1.4 | Document Content Schema Design |  | 5d | 2006-01-02 | 2006-01-06 |  | 0d | Architect | 40h |
| 279 | 9.1.5 | Document design for UI including themes and skins |  | 2d | 2006-01-02 | 2006-01-03 |  | 0d | Development Lead | 16h |
| 280 | 9.1.6 | Review and update use/test cases |  | 5d | 2006-01-02 | 2006-01-06 |  | 0d | Test Lead | 40h |
| 281 | 9.1.7 | Review designs |  | 2d | 2006-01-02 | 2006-01-03 |  | 0d | Development Lead; Architect; Project Manager | 48h |
| 282 | 9.2 | **Build** |  | 15d? | 2006-01-01 | 2006-01-20 |  | 0d |  | 240h |
| 283 | 9.2.1 | **Interative Development** |  | 15d? | 2006-01-01 | 2006-01-20 |  | 0d |  | 240h |
| 284 | 9.2.1.1 | Develop/test phase 3 of custom development |  | 15d | 2006-01-02 | 2006-01-20 |  | 0d | Developers | 120h |
| 285 | 9.2.1.2 | Develop/test phase 4 of custom development |  | 15d | 2006-01-02 | 2006-01-20 |  | 0d | Developers | 120h |
| 286 | 9.2.1.3 | **Content Development** |  | 0d? | 2006-01-01 | 2006-01-01 |  | 0d |  |  |
| 287 | 9.2.1.3.1 | Content Inventory | milestone | 0d? | 2006-01-01 | 2006-01-01 |  | 0d | Development Lead |  |
| 288 | 9.2.1.3.2 | Content Written | milestone | 0d? | 2006-01-01 | 2006-01-01 |  | 0d | Development Lead |  |
| 289 | 9.2.1.3.3 | Content Tagged | milestone | 0d? | 2006-01-01 | 2006-01-01 |  | 0d | Development Lead |  |
| 290 | 9.2.1.3.4 | Content Complete | milestone | 0d? | 2006-01-01 | 2006-01-01 |  | 0d | Development Lead |  |
| 291 | 9.3 | **Test** |  | 10d? | 2006-01-02 | 2006-01-13 |  | 0d |  | 440h |
| 292 | 9.3.1 | QA/IntegrationTesting |  | 10d? | 2006-01-02 | 2006-01-13 |  | 0d | Test Lead | 80h |
| 293 | 9.3.2 | System Test |  | 5d? | 2006-01-02 | 2006-01-06 |  | 0d | Test Lead | 40h |
| 294 | 9.3.3 | **Performance/Stress Test** |  | 10d | 2006-01-02 | 2006-01-13 |  | 0d |  | 320h |
| 295 | 9.3.3.1 | Develop Performance Scripts |  | 5d | 2006-01-02 | 2006-01-06 |  | 0d | Test Lead; Infrastructure Lead | 80h |
| 296 | 9.3.3.2 | Stress Testing |  | 5d | 2006-01-02 | 2006-01-06 |  | 0d | Test Lead; Infrastructure Lead | 80h |
| 297 | 9.3.3.3 | Failover Testing |  | 5d | 2006-01-02 | 2006-01-06 |  | 0d | Test Lead; Infrastructure Lead | 80h |
| 298 | 9.3.3.4 | Adjust and confirm |  | 5d | 2006-01-09 | 2006-01-13 | 297 | 0d | Test Lead; Infrastructure Lead | 80h |

Notes:
- 271: The production release is sometimes referred to as "Release 1." This is because most IT systems go thru several release cycles. This basic pattern can be repeated for each release.
- 286: Most portals deliver dynamic content, web pages that are selected based on some customization or personalization. But the actual nature of each organization is so different, no general guidelines for task time can be made.

| ID | WBS | Task | Type | Duration | Start | Finish | Predecessors | Total slack | Resources | Work |
| --- | --- | --- | --- | --- | --- | --- | --- | --- | --- | --- |
| 299 | 9.4 | **Deployment** |  | 10d? | 2006-01-01 | 2006-01-13 |  | 0d |  | 376h |
| 300 | 9.4.1 | Develop/Test Install Guide/Scripts (Ant) |  | 5d | 2006-01-02 | 2006-01-06 |  | 0d | Infrastructure Lead | 40h |
| 301 | 9.4.2 | Deploy Tested Portal/Portlets |  | 10d | 2006-01-02 | 2006-01-13 |  | 0d | Infrastructure Lead | 80h |
| 302 | 9.4.3 | Develop/Test Disaster Recovery Procedures |  | 5d | 2006-01-02 | 2006-01-06 |  | 0d | Infrastructure Lead | 40h |
| 303 | 9.4.4 | Document Operator Procedures |  | 5d | 2006-01-02 | 2006-01-06 |  | 0d | Infrastructure Lead | 40h |
| 304 | 9.4.5 | Operator Training |  | 1d? | 2006-01-02 | 2006-01-02 |  | 0d | Infrastructure Lead; Project Owner | 16h |
| 305 | 9.4.6 | Establish End User Documentation/Training | milestone | 0d? | 2006-01-01 | 2006-01-01 |  | 0d | Project Owner |  |
| 306 | 9.4.7 | Deployment Readiness Assessment |  | 3d | 2006-01-02 | 2006-01-04 |  | 0d | Infrastructure Lead; Project Owner; Project Manager; IBM Services | 96h |
| 307 | 9.4.8 | Go/No-Go Decision |  | 1d? | 2006-01-02 | 2006-01-02 |  | 0d | Project Owner | 8h |
| 308 | 9.4.9 | Go Live |  | 1d? | 2006-01-03 | 2006-01-03 | 307 | 0d | Project Owner | 8h |
| 309 | 9.4.10 | Issue Management |  | 2d | 2006-01-02 | 2006-01-03 |  | 0d | Project Owner; Project Manager; Architect | 48h |
| 310 | 10 | **Project Close** |  | 2d | 2006-01-02 | 2006-01-03 |  | 0d |  | 96h |
| 311 | 10.1 | **Review Results vs. Objectives** |  | 2d | 2006-01-02 | 2006-01-03 |  | 0d |  | 32h |
| 312 | 10.1.1 | Functional Results |  | 2d | 2006-01-02 | 2006-01-03 |  | 0d | Development Lead | 16h |
| 313 | 10.1.2 | Performance Results |  | 1d | 2006-01-02 | 2006-01-02 |  | 0d | Architect | 8h |
| 314 | 10.1.3 | Project Schedule Results |  | 0.5d | 2006-01-02 | 2006-01-02 |  | 0d | Project Manager | 4h |
| 315 | 10.1.4 | Skills Results |  | 0.5d | 2006-01-02 | 2006-01-02 |  | 0d | Project Owner | 4h |
| 316 | 10.2 | Document Lessons Learned |  | 1d | 2006-01-02 | 2006-01-02 |  | 0d | Development Lead; Infrastructure Lead; Architect; Test Lead | 32h |
| 317 | 10.3 | Develop Follow-On Plans |  | 2d | 2006-01-02 | 2006-01-03 |  | 0d | Project Owner; Project Manager | 32h |
